# Simultrain mit Dummy Ressourcen 3 Perioden

Schedule from MS Project, 2015-01-05 to 2015-05-01, status date 2015-01-05, costs in €.

## Calendars

- DE - Standard: Mon-Fri 08:00-12:00, 13:00-17:00; Sat-Sun off.

## Resources

| Resource | Rate |
| --- | --- |
| Eventmanagement | 1738 |
| Alex | 86 |
| Anna | 160 |
| Felix | 89 |
| Fred (Kernteam) | 89 |
| Hans | 135 |
| John | 125 |
| Livio | 97 |
| Luc | 70 |
| Marco | 89 |
| Paul | 175 |
| Peter | 128 |
| Sue (Kernteam) | 151 |
| Ted | 58 |
| Tim (Kernteam) | 97 |

## Schedule

| ID | Task | Duration | Start | Finish | Predecessors | Total slack | Free slack | Constraint | Resources | Work | Cost |
| --- | --- | --- | --- | --- | --- | --- | --- | --- | --- | --- | --- |
| 1 | Initialplanung | 5d | 2015-01-05 | 2015-01-09 |  | 9.5d | 3d | start no earlier than 2015-01-05 | Fred (Kernteam); Tim (Kernteam) | 80h | 7,440 |
| 2 | Akkreditierung | 7d | 2015-01-19 | 2015-02-03 | 1 | 22.5d | 16d | start no earlier than 2015-01-19 | Ted | 56h | 3,248 |
| 3 | Marketingplan | 10d | 2015-01-15 | 2015-01-28 | 1 | 18.5d | 12d | start no earlier than 2015-01-15 | Hans; Peter | 160h | 21,040 |
| 4 | Sponsorschaft | 17d | 2015-01-15 | 2015-02-13 | 1 | 6.5d | 0d | start no earlier than 2015-01-15 | Anna; Livio | 192h | 24,672 |
| 5 | Finanzplanung | 8d | 2015-02-16 | 2015-02-25 | 3, 4 | 6.5d | 0d | start no earlier than 2015-02-16 | John; Luc | 128h | 12,480 |
| 6 | Venue - Plan | 13d | 2015-02-26 | 2015-03-16 | 2, 5 | 6.5d | 0d | start no earlier than 2015-02-26 | Fred (Kernteam); Ted | 208h | 15,288 |
| 7 | Logistik | 15d | 2015-02-26 | 2015-03-18 | 5 | 16.5d | 15d | start no earlier than 2015-02-26 | Anna; Felix; Hans; Paul | 480h | 67,080 |
| 8 | Vorbereitung des Protokolls | 14d | 2015-03-17 | 2015-04-03 | 5 | 14.5d | 13d | start no earlier than 2015-03-17 | John; Livio; Ted | 336h | 31,360 |
| 9 | Ärztlicher Notdienst | 5d | 2015-02-26 | 2015-03-04 | 5 | 26.5d | 25d | start no earlier than 2015-02-26 | Alex; Luc; Marco | 120h | 9,800 |
| 10 | Kommuniktionsplan | 3.33d | 2015-02-16 | 2015-02-19 | 4 | 24.17d | 17.67d | start no earlier than 2015-02-16 | Marco; Paul; Ted | 80h | 8,586.67 |
| 11 | Fernsehübertragung | 22d | 2015-03-17 | 2015-04-15 | 6, 10 | 6.5d | 5d | start no earlier than 2015-03-17 | Alex | 176h | 15,136 |
| 12 | Risikoplan | 8d | 2015-01-15 | 2015-01-26 | 1 | 42.5d | 27d | start no earlier than 2015-01-15 | Fred (Kernteam); Sue (Kernteam) | 128h | 15,360 |
| 13 | Transport | 11d | 2015-03-05 | 2015-03-19 | 12 | 15.5d | 14d | start no earlier than 2015-03-05 | Luc; Marco; Peter; Sue (Kernteam) | 352h | 38,544 |
| 14 | Equipment | 10d | 2015-04-09 | 2015-04-22 | 7, 9, 13 | 1.5d | 0d | start no earlier than 2015-04-09 | Luc | 80h | 5,600 |
| 15 | Service - Test | 3d | 2015-04-23 | 2015-04-27 | 8, 11, 14 | 1.5d |  | start no earlier than 2015-04-23 | Alex; Anna; Ted | 72h | 7,296 |
| 16 | Kontrolle | 22.5d | 2015-01-15 | 2015-03-02 | 1 | 42d |  | start no earlier than 2015-01-15 | Tim (Kernteam) | 180h | 17,460 |
| 17 | Offizielle Freigabe | 2d | 2015-04-29 | 2015-05-01 | 15, 16 | 0d |  | start no earlier than 2015-04-29 | Fred (Kernteam); Sue (Kernteam); Ted; Tim (Kernteam) | 64h | 6,320 |
