# Simultrain mit Dummy Ressourcen

Schedule from MS Project, 2015-01-05 to 2015-03-16, status date 2015-01-05, costs in €.

## Calendars

- DE - Standard: Mon-Fri 08:00-12:00, 13:00-17:00; Sat-Sun off.

## Resources

| Resource | Rate |
| --- | --- |
| Eventmanagement | 1738 |
| Alex | 86 |
| Anna | 160 |
| Felix | 89 |
| Fred (Kernteam) | 89 |
| Hans | 135 |
| John | 125 |
| Livio | 97 |
| Luc | 70 |
| Marco | 89 |
| Paul | 175 |
| Peter | 128 |
| Sue (Kernteam) | 151 |
| Ted | 58 |
| Tim (Kernteam) | 97 |

## Schedule

| ID | Task | Duration | Start | Finish | Predecessors | Total slack | Free slack | Constraint | Resources | Work | Cost |
| --- | --- | --- | --- | --- | --- | --- | --- | --- | --- | --- | --- |
| 1 | Initialplanung | 4d | 2015-01-05 | 2015-01-08 |  | 10.75d | 4d | start no earlier than 2015-01-05 | Fred (Kernteam); Tim (Kernteam) | 64h | 5,952 |
| 2 | Akkreditierung | 4d | 2015-01-15 | 2015-01-20 | 1 | 22.75d | 18d | start no earlier than 2015-01-15 |  | 32h |  |
| 3 | Marketingplan | 5d | 2015-01-15 | 2015-01-21 | 1 | 17.75d | 13d | start no earlier than 2015-01-15 | Hans; Peter | 80h | 10,520 |
| 4 | Sponsorschaft | 6d | 2015-01-15 | 2015-01-22 | 1 | 6.75d | 12d | start no earlier than 2015-01-15 | Anna; Livio | 96h | 12,336 |
| 5 | Finanzplanung | 4d | 2015-02-10 | 2015-02-13 | 3, 4 | 4.75d | 0d | start no earlier than 2015-02-10 | John; Luc | 64h | 6,240 |
| 6 | Venue - Plan | 6d | 2015-02-16 | 2015-02-23 | 2, 5 | 4.75d | 2.75d | start no earlier than 2015-02-16 | Fred (Kernteam); Ted | 96h | 7,056 |
| 7 | Logistik | 7d | 2015-02-16 | 2015-02-24 | 5 | 6.75d | 3.75d | start no earlier than 2015-02-16 | Felix; Hans | 112h | 12,544 |
| 8 | Vorbereitung des Protokolls | 9d | 2015-02-16 | 2015-02-26 | 5 | 7.75d | 5.75d | start no earlier than 2015-02-16 | John; Livio | 144h | 15,984 |
| 9 | Ärztlicher Notdienst | 5d | 2015-02-16 | 2015-02-20 | 5 | 8.75d | 5.75d | start no earlier than 2015-02-16 | Luc; Marco | 80h | 6,360 |
| 10 | Kommuniktionsplan | 4d | 2015-02-10 | 2015-02-13 | 4 | 10.75d | 8.75d | start no earlier than 2015-02-10 | Marco; Paul | 64h | 8,448 |
| 11 | Fernsehübertragung | 6d | 2015-02-26 | 2015-03-06 | 6, 10 | 2d | 0d | start no earlier than 2015-02-26 | Alex | 48h | 4,128 |
| 12 | Risikoplan | 6d | 2015-01-15 | 2015-01-22 | 1 | 16.75d | 6d | start no earlier than 2015-01-15 | Fred (Kernteam); Sue (Kernteam) | 96h | 11,520 |
| 13 | Transport | 11d | 2015-02-02 | 2015-02-18 | 12 | 10.75d | 7.75d | start no earlier than 2015-02-02 | Peter; Sue (Kernteam) | 128h | 17,856 |
| 14 | Equipment | 3d | 2015-03-02 | 2015-03-05 | 7, 9, 13 | 3d | 1d | start no earlier than 2015-03-02 | Luc | 24h | 1,680 |
| 15 | Service - Test | 2d | 2015-03-06 | 2015-03-10 | 8, 11, 14 | 2d |  | start no earlier than 2015-03-06 | Alex; Anna | 32h | 3,936 |
| 16 | Kontrolle | 15d | 2015-01-15 | 2015-02-04 | 1 | 15.75d | 25.75d | start no earlier than 2015-01-15 | Tim (Kernteam) | 120h | 11,640 |
| 17 | Offizielle Freigabe | 2d | 2015-03-12 | 2015-03-16 | 15, 16 | 0d |  | start no earlier than 2015-03-12 | Fred (Kernteam); Sue (Kernteam); Tim (Kernteam) | 48h | 5,392 |
